# Lab Build Project - Sample

Schedule from MS Project, 2009-01-05 to 2009-02-27.
Project Management
Applied Management Centre

## Calendars

- Standard: Mon-Fri 08:00-12:00, 13:00-17:00; Sat-Sun off.

## Resources

| Resource | Group | Unit | Notes |
| --- | --- | --- | --- |
| Project Manager | Administration |  |  |
| Information Systems Director | Administration |  | Vacation: June 29 - July 10 |
| Facilities Manager | Administration |  |  |
| Procurement Manager | Administration |  |  |
| Interior Designer | Design |  |  |
| Architect | Design |  |  |
| Mechanical Consultant | Design |  |  |
| Electrical Consultant | Design |  |  |
| Security Consultant | Design |  |  |
| Communications Consultant | Design |  |  |
| General Contractor | General Contractor |  | Only 8 people available Aug 1-9 |
| Chairs | Furniture | chairs |  |
| Student workstations | Furniture | desks |  |
| Projectors | Equipment | units |  |
| Whiteboards | Furniture | boards |  |
| Screens | Furniture | units |  |
| Tables | Furniture | tables |  |
| Instructor workstations | Furniture | desks |  |
| PC systems | Equipment | PCs |  |
| Displays | Equipment | monitors |  |
| Mac systems | Equipment | Macs |  |
| Scanners | Equipment | scanners |  |
| Printers | Equipment | printers |  |

## Schedule

| ID | WBS | Task | Type | Duration | Start | Finish | Total slack | Resources | Work |
| --- | --- | --- | --- | --- | --- | --- | --- | --- | --- |
| 1 | 1 | Project approved | milestone | 0d | 2009-01-05 | 2009-01-05 | 1d |  |  |
| 2 | 2 | **Project Management** |  | 40d | 2009-01-05 | 2009-02-27 | 0d |  | 496h |
| 3 | 2.1 | Plan project |  | 40d | 2009-01-05 | 2009-02-27 | 0d | Project Manager [37.5%]; Procurement Manager [12.5%]; Facilities Manager [12.5%]; Information Systems Director [12.5%]; Architect; General Contractor; Mechanical Consultant; Electrical Consultant; Communications Consultant; Security Consultant; Interior Designer | 352h |
| 4 | 2.2 | Monitor & control project |  | 20d | 2009-01-05 | 2009-01-30 | 20d | Project Manager [20%]; Procurement Manager [5%]; Information Systems Director [5%]; Facilities Manager [5%] | 32h |
| 5 | 2.3 | Close project |  | 5d | 2009-01-05 | 2009-01-09 | 35d | Project Manager; Information Systems Director; Facilities Manager; Procurement Manager; Architect; General Contractor; Interior Designer | 112h |
| 6 | 3 | **Design** |  | 20d | 2009-01-05 | 2009-01-30 | 20d |  | 808h |
| 7 | 3.1 | Analyse lab requirements |  | 10d | 2009-01-05 | 2009-01-16 | 30d | Information Systems Director [20%]; Facilities Manager [20%]; Procurement Manager [20%]; Interior Designer [20%]; Architect [20%]; Mechanical Consultant [20%]; Electrical Consultant [20%]; Security Consultant [20%]; Communications Consultant [20%] | 144h |
| 8 | 3.2 | Develop furniture specs |  | 15d | 2009-01-05 | 2009-01-23 | 25d | Facilities Manager [6.7%]; Interior Designer [33.3%] | 48h |
| 9 | 3.3 | Develop equipment specs |  | 15d | 2009-01-05 | 2009-01-23 | 25d | Information Systems Director [26.7%] | 32h |
| 10 | 3.4 | **Design lab interiors** |  | 20d | 2009-01-05 | 2009-01-30 | 20d |  | 144h |
| 11 | 3.4.1 | Design lab interiors - Borlaug |  | 20d | 2009-01-05 | 2009-01-30 | 20d | Interior Designer [20%] | 32h |
| 12 | 3.4.2 | Design lab interiors - Marquez |  | 20d | 2009-01-05 | 2009-01-30 | 20d | Interior Designer [20%] | 32h |
| 13 | 3.4.3 | Design lab interiors - Salam |  | 20d | 2009-01-05 | 2009-01-30 | 20d | Interior Designer [25%] | 40h |
| 14 | 3.4.4 | Design lab interiors - Sen |  | 20d | 2009-01-05 | 2009-01-30 | 20d | Interior Designer [25%] | 40h |
| 15 | 3.5 | **Develop construction documents** |  | 10d | 2009-01-05 | 2009-01-16 | 30d |  | 440h |
| 16 | 3.5.1 | Develop architectural specs |  | 10d | 2009-01-05 | 2009-01-16 | 30d | Architect | 80h |
| 17 | 3.5.2 | Develop structural specs |  | 10d | 2009-01-05 | 2009-01-16 | 30d | Architect | 80h |
| 18 | 3.5.3 | Develop electrical specs |  | 10d | 2009-01-05 | 2009-01-16 | 30d | Electrical Consultant | 80h |
| 19 | 3.5.4 | Develop mechanical specs |  | 10d | 2009-01-05 | 2009-01-16 | 30d | Mechanical Consultant | 80h |
| 20 | 3.5.5 | Develop communications/data specs |  | 10d | 2009-01-05 | 2009-01-16 | 30d | Communications Consultant | 80h |
| 21 | 3.5.6 | Develop security specs |  | 5d | 2009-01-05 | 2009-01-09 | 35d | Security Consultant | 40h |
| 22 | 4 | **Construction** |  | 8d | 2009-01-05 | 2009-01-14 | 32d |  | 1040h |
| 23 | 4.1 | **Borlaug Building** |  | 8d | 2009-01-05 | 2009-01-14 | 32d |  | 208h |
| 24 | 4.1.1 | Build Lab B107 |  | 5d | 2009-01-05 | 2009-01-09 | 35d | General Contractor [200%]; Chairs [21 chairs]; Student workstations [20 desks]; Instructor workstations [1 desks]; Whiteboards [4 boards]; Screens [2 units]; Tables [2 tables]; Projectors [2 units]; PC systems [21 PCs]; Displays [21 monitors]; Scanners [1 scanners]; Printers [1 printers] | 80h |
| 25 | 4.1.2 | Build Lab B108 |  | 8d | 2009-01-05 | 2009-01-14 | 32d | Chairs [31 chairs]; Displays [31 monitors]; General Contractor [200%]; Instructor workstations [1 desks]; PC systems [31 PCs]; Projectors [2 units]; Scanners [1 scanners]; Screens [2 units]; Tables [2 tables]; Whiteboards [4 boards]; Student workstations [30 desks]; Printers [1 printers] | 128h |

Notes:
- 3: Consultants assigned with a delay to accommodate procurement process.
- 4: This task has been set to Fixed Units to simplify estimation. / Duration and work to be adjusted after activities sequencing and resource leveling.
- 25: Previously existing lab

| ID | WBS | Task | Type | Duration | Start | Finish | Total slack | Deadline | Resources | Work |
| --- | --- | --- | --- | --- | --- | --- | --- | --- | --- | --- |
| 26 | 4.2 | **Marquez Library** |  | 7d | 2009-01-05 | 2009-01-13 | 33d |  |  | 208h |
| 27 | 4.2.1 | Build Lab L315 |  | 7d | 2009-01-05 | 2009-01-13 | 33d |  | Chairs [31 chairs]; Displays [31 monitors]; General Contractor [200%]; Instructor workstations [1 desks]; PC systems [31 PCs]; Projectors [2 units]; Scanners [1 scanners]; Screens [2 units]; Tables [2 tables]; Whiteboards [4 boards]; Student workstations [30 desks]; Printers [1 printers] | 112h |
| 28 | 4.2.2 | Build Lab L316 |  | 6d | 2009-01-05 | 2009-01-12 | 34d |  | Chairs [21 chairs]; General Contractor [200%]; Instructor workstations [1 desks]; Mac systems [21 Macs]; Projectors [2 units]; Scanners [1 scanners]; Screens [2 units]; Tables [2 tables]; Whiteboards [4 boards]; Student workstations [20 desks]; Printers [1 printers] | 96h |
| 29 | 4.3 | **Salam Center** |  | 8d | 2009-01-05 | 2009-01-14 | 32d |  |  | 320h |
| 30 | 4.3.1 | Build Lab S324 |  | 5d | 2009-01-05 | 2009-01-09 | 35d |  | Chairs [21 chairs]; Displays [21 monitors]; General Contractor [200%]; Instructor workstations [1 desks]; PC systems [21 PCs]; Projectors [2 units]; Scanners [1 scanners]; Screens [2 units]; Tables [2 tables]; Whiteboards [4 boards]; Student workstations [20 desks]; Printers [1 printers] | 80h |
| 31 | 4.3.2 | Build Lab S325 |  | 7d | 2009-01-05 | 2009-01-13 | 33d |  | Chairs [26 chairs]; Displays [26 monitors]; General Contractor [200%]; Instructor workstations [1 desks]; PC systems [26 PCs]; Projectors [2 units]; Scanners [1 scanners]; Screens [2 units]; Tables [2 tables]; Whiteboards [4 boards]; Student workstations [25 desks]; Printers [1 printers] | 112h |
| 32 | 4.3.3 | Build Lab S326 |  | 8d | 2009-01-05 | 2009-01-14 | 32d |  | Chairs [31 chairs]; Displays [31 monitors]; General Contractor [200%]; Instructor workstations [1 desks]; PC systems [31 PCs]; Projectors [2 units]; Scanners [1 scanners]; Screens [2 units]; Tables [2 tables]; Whiteboards [4 boards]; Student workstations [30 desks]; Printers [1 printers] | 128h |
| 33 | 4.4 | **Sen Building** |  | 8d | 2009-01-05 | 2009-01-14 | 32d |  |  | 304h |
| 34 | 4.4.1 | Build Lab E210 |  | 5d | 2009-01-05 | 2009-01-09 | 35d |  | Chairs [21 chairs]; Displays [21 monitors]; General Contractor [200%]; Instructor workstations [1 desks]; PC systems [21 PCs]; Projectors [2 units]; Scanners [1 scanners]; Screens [2 units]; Tables [2 tables]; Whiteboards [4 boards]; Student workstations [20 desks]; Printers [1 printers] | 80h |
| 35 | 4.4.2 | Build Lab E211 |  | 6d | 2009-01-05 | 2009-01-12 | 34d |  | Chairs [26 chairs]; Displays [26 monitors]; General Contractor [200%]; Instructor workstations [1 desks]; PC systems [26 PCs]; Projectors [2 units]; Scanners [1 scanners]; Screens [2 units]; Tables [2 tables]; Whiteboards [4 boards]; Student workstations [25 desks]; Printers [1 printers] | 96h |
| 36 | 4.4.3 | Build Lab E212 |  | 8d | 2009-01-05 | 2009-01-14 | 32d |  | Chairs [31 chairs]; Displays [31 monitors]; General Contractor [200%]; Instructor workstations [1 desks]; PC systems [31 PCs]; Projectors [2 units]; Scanners [1 scanners]; Screens [2 units]; Tables [2 tables]; Whiteboards [4 boards]; Student workstations [30 desks]; Printers [1 printers] | 128h |
| 37 | 5 | **Commissioning** |  | 20d | 2009-01-05 | 2009-01-30 | 20d |  |  | 224h |
| 38 | 5.1 | Test all labs |  | 2d | 2009-01-05 | 2009-01-06 | 38d |  | Project Manager; Information Systems Director | 32h |
| 39 | 5.2 | Produce as-built documents for all labs |  | 15d | 2009-01-05 | 2009-01-23 | 25d |  | Interior Designer [13.3%]; Architect [13.3%]; Mechanical Consultant [13.3%]; Electrical Consultant [13.3%]; Security Consultant [13.3%]; Communications Consultant [13.3%]; General Contractor [13.3%] | 112h |
| 40 | 5.3 | Produce operations and maintenance manuals |  | 20d | 2009-01-05 | 2009-01-30 | 20d |  | Information Systems Director [25%]; Facilities Manager [25%] | 80h |
| 41 | 6 | Project complete | milestone | 0d | 2009-01-05 | 2009-01-05 | 1d | 2009-08-31 |  |  |

Notes:
- 28: Previously existing lab
- 31: Previously existing lab
- 32: Previously existing lab
- 36: Previously existing lab
