# Lab Build Project - Sample

Schedule from MS Project, 2009-01-05 to 2009-08-28, costs in $.
Project Management
Applied Management Centre

## Calendars

- Standard: Mon-Fri 08:00-12:00, 13:00-17:00; Sat-Sun off. Exceptions (off unless hours are given): 2009-04-10, 2009-05-18, 2009-07-01, 2009-08-03.

## Resources

| Resource | Group | Unit | Rate | Notes |
| --- | --- | --- | --- | --- |
| Project Manager | Administration |  | 35 | Cost rate table A - unloaded rate / Cost rate table B - loaded rate |
| Information Systems Director | Administration |  | 40 | Vacation: June 29 - July 10 / Cost rate table A - unloaded rate / Cost rate table B - loaded rate |
| Facilities Manager | Administration |  | 30 | Cost rate table A - unloaded rate / Cost rate table B - loaded rate |
| Procurement Manager | Administration |  | 30 | Cost rate table A - unloaded rate / Cost rate table B - loaded rate |
| Interior Designer | Design |  | 100 |  |
| Architect | Design |  | 150 |  |
| Mechanical Consultant | Design |  | 150 |  |
| Electrical Consultant | Design |  | 150 |  |
| Security Consultant | Design |  | 150 |  |
| Communications Consultant | Design |  | 150 |  |
| General Contractor | General Contractor |  |  | Only 8 people available Aug 1-9 / Costs are inserted as Contract Costs to represent Fixed Price contract of $200,000 |
| Chairs | Furniture | chairs | 100 |  |
| Student workstations | Furniture | desks | 500 |  |
| Projectors | Equipment | units | 2000 |  |
| Whiteboards | Furniture | boards | 500 |  |
| Screens | Furniture | units | 600 |  |
| Tables | Furniture | tables | 300 |  |
| Instructor workstations | Furniture | desks | 1000 |  |
| PC systems | Equipment | PCs | 3000 |  |
| Displays | Equipment | monitors | 500 |  |
| Mac systems | Equipment | Macs | 3500 |  |
| Scanners | Equipment | scanners | 300 |  |
| Printers | Equipment | printers | 500 |  |

## Schedule

| ID | WBS | Task | Type | Duration | Start | Finish | Predecessors | Baseline start | Baseline finish | Baseline duration | Total slack | Free slack | Resources | Work | Cost | Baseline cost |
| --- | --- | --- | --- | --- | --- | --- | --- | --- | --- | --- | --- | --- | --- | --- | --- | --- |
| 1 | 1 | Project approved | milestone | 0d | 2009-01-05 | 2009-01-05 |  | 2009-01-05 | 2009-01-05 | 0d | 0d |  |  |  |  |  |
| 2 | 2 | **Project Management** |  | 166d | 2009-01-05 | 2009-08-28 |  | 2009-01-05 | 2009-08-28 | 166d | 0d |  |  | 792h | 38,080 | 38,080 |
| 3 | 2.1 | Plan project |  | 40d | 2009-01-05 | 2009-02-27 | 1 | 2009-01-05 | 2009-02-27 | 40d | 0d |  | Project Manager [37.5%]; Procurement Manager [12.5%]; Facilities Manager [12.5%]; Information Systems Director [12.5%]; Architect; General Contractor; Mechanical Consultant; Electrical Consultant; Communications Consultant; Security Consultant; Interior Designer | 352h | 21,800 | 21,800 |
| 4 | 2.2 | Monitor & control project |  | 121d | 2009-03-02 | 2009-08-21 | 3 | 2009-03-02 | 2009-08-21 | 121d | 0d |  | Project Manager [19.8%]; Procurement Manager [5%]; Information Systems Director [5%]; Facilities Manager [5%] | 328h | 11,200 | 11,200 |
| 5 | 2.3 | Close project |  | 5d | 2009-08-24 | 2009-08-28 | 4, 43, 44, 45 | 2009-08-24 | 2009-08-28 | 5d | 0d |  | Project Manager; Information Systems Director; Facilities Manager; Procurement Manager; Architect; General Contractor; Interior Designer | 112h | 5,080 | 5,080 |
| 6 | 3 | Project plan approved | milestone | 0d | 2009-02-27 | 2009-02-27 | 3 | 2009-02-27 | 2009-02-27 | 0d | 126d |  |  |  |  |  |
| 7 | 4 | **Design** |  | 45d | 2009-03-02 | 2009-05-04 |  | 2009-03-02 | 2009-05-04 | 45d | 42d |  |  | 808h | 101,120 | 101,120 |
| 8 | 4.1 | Analyse lab requirements |  | 10d | 2009-03-02 | 2009-03-13 | 3 | 2009-03-02 | 2009-03-13 | 10d | 42d | 0d | Information Systems Director [20%]; Facilities Manager [20%]; Procurement Manager [20%]; Interior Designer [20%]; Architect [20%]; Mechanical Consultant [20%]; Electrical Consultant [20%]; Security Consultant [20%]; Communications Consultant [20%] | 144h | 15,200 | 15,200 |
| 9 | 4.2 | Develop furniture specs |  | 15d | 2009-03-16 | 2009-04-03 | 8 | 2009-03-16 | 2009-04-03 | 15d | 42d | 0d | Facilities Manager [6.7%]; Interior Designer [33.3%] | 48h | 4,240 | 4,240 |
| 10 | 4.3 | Develop equipment specs |  | 15d | 2009-03-16 | 2009-04-03 | 8 | 2009-03-16 | 2009-04-03 | 15d | 52d | 0d | Information Systems Director [26.7%] | 32h | 1,280 | 1,280 |
| 11 | 4.4 | **Design lab interiors** |  | 20d | 2009-04-06 | 2009-05-04 |  | 2009-04-06 | 2009-05-04 | 20d | 42d |  |  | 144h | 14,400 | 14,400 |
| 12 | 4.4.1 | Design lab interiors - Borlaug |  | 20d | 2009-04-06 | 2009-05-04 | 9 | 2009-04-06 | 2009-05-04 | 20d | 52d | 42d | Interior Designer [20%] | 32h | 3,200 | 3,200 |
| 13 | 4.4.2 | Design lab interiors - Marquez |  | 20d | 2009-04-06 | 2009-05-04 | 9 | 2009-04-06 | 2009-05-04 | 20d | 50d | 0d | Interior Designer [20%] | 32h | 3,200 | 3,200 |
| 14 | 4.4.3 | Design lab interiors - Salam |  | 20d | 2009-04-06 | 2009-05-04 | 9 | 2009-04-06 | 2009-05-04 | 20d | 42d | 0d | Interior Designer [25%] | 40h | 4,000 | 4,000 |
| 15 | 4.4.4 | Design lab interiors - Sen |  | 20d | 2009-04-06 | 2009-05-04 | 9 | 2009-04-06 | 2009-05-04 | 20d | 43d | 0d | Interior Designer [25%] | 40h | 4,000 | 4,000 |
| 16 | 4.5 | **Develop construction documents** |  | 25d | 2009-03-16 | 2009-04-20 |  | 2009-03-16 | 2009-04-20 | 25d | 52d | 10d |  | 440h | 66,000 | 66,000 |
| 17 | 4.5.1 | Develop architectural specs |  | 10d | 2009-03-16 | 2009-03-27 | 8 | 2009-03-16 | 2009-03-27 | 10d | 67d | 15d | Architect | 80h | 12,000 | 12,000 |
| 18 | 4.5.2 | Develop structural specs |  | 10d | 2009-03-30 | 2009-04-13 | 8 | 2009-03-30 | 2009-04-13 | 10d | 57d | 5d | Architect | 80h | 12,000 | 12,000 |
| 19 | 4.5.3 | Develop electrical specs |  | 10d | 2009-04-06 | 2009-04-20 | 10 | 2009-04-06 | 2009-04-20 | 10d | 52d | 0d | Electrical Consultant | 80h | 12,000 | 12,000 |
| 20 | 4.5.4 | Develop mechanical specs |  | 10d | 2009-04-06 | 2009-04-20 | 10 | 2009-04-06 | 2009-04-20 | 10d | 52d | 0d | Mechanical Consultant | 80h | 12,000 | 12,000 |
| 21 | 4.5.5 | Develop communications/data specs |  | 10d | 2009-04-06 | 2009-04-20 | 10 | 2009-04-06 | 2009-04-20 | 10d | 52d | 0d | Communications Consultant | 80h | 12,000 | 12,000 |
| 22 | 4.5.6 | Develop security specs |  | 5d | 2009-03-16 | 2009-03-20 | 8 | 2009-03-16 | 2009-03-20 | 5d | 72d | 20d | Security Consultant | 40h | 6,000 | 6,000 |
| 23 | 5 | Lab requirements complete | milestone | 0d | 2009-03-13 | 2009-03-13 | 8 | 2009-03-13 | 2009-03-13 | 0d | 87d | 77d |  |  |  |  |
| 24 | 6 | Construction documents complete | milestone | 0d | 2009-04-20 | 2009-04-20 | 17, 18, 19, 20, 21, 22 | 2009-04-20 | 2009-04-20 | 0d | 91d |  |  |  |  |  |
| 25 | 7 | Designs complete | milestone | 0d | 2009-05-04 | 2009-05-04 | 9, 10, 16, 13, 14, 15, 17, 18, 19, 20, 21, 22 | 2009-05-04 | 2009-05-04 | 0d | 81d |  |  |  |  |  |

Notes:
- 3: Consultants assigned with a delay to accommodate procurement process.
- 4: This task has been set to Fixed Units to simplify estimation. / Duration and work to be adjusted after activities sequencing and resource leveling.

| ID | WBS | Task | Type | Duration | Start | Finish | Predecessors | Baseline start | Baseline finish | Baseline duration | Total slack | Free slack | Constraint | Deadline | Resources | Work | Cost | Baseline cost |
| --- | --- | --- | --- | --- | --- | --- | --- | --- | --- | --- | --- | --- | --- | --- | --- | --- | --- | --- |
| 26 | 8 | **Construction** |  | 21d | 2009-07-06 | 2009-08-04 |  | 2009-07-06 | 2009-08-04 | 21d | 13d |  | start no earlier than 2009-07-06 |  |  | 1040h | 1,357,000 | 1,357,000 |
| 27 | 8.1 | **Borlaug Building** |  | 13d | 2009-07-06 | 2009-07-22 |  | 2009-07-06 | 2009-07-22 | 13d | 8d |  |  |  |  | 208h | 271,400 | 271,400 |
| 28 | 8.1.1 | Build Lab B107 |  | 5d | 2009-07-16 | 2009-07-22 | 12, 17, 18, 19, 20, 21, 23 | 2009-07-16 | 2009-07-22 | 5d | 8d |  |  |  | General Contractor [200%]; Chairs [21 chairs]; Student workstations [20 desks]; Instructor workstations [1 desks]; Whiteboards [4 boards]; Screens [2 units]; Tables [2 tables]; Projectors [2 units]; PC systems [21 PCs]; Displays [21 monitors]; Scanners [1 scanners]; Printers [1 printers] | 80h | 115,200 | 115,200 |
| 29 | 8.1.2 | Build Lab B108 |  | 8d | 2009-07-06 | 2009-07-15 | 12, 17, 18, 19, 20, 21, 22 | 2009-07-06 | 2009-07-15 | 8d | 13d |  |  |  | Chairs [31 chairs]; Displays [31 monitors]; General Contractor [200%]; Instructor workstations [1 desks]; PC systems [31 PCs]; Projectors [2 units]; Scanners [1 scanners]; Screens [2 units]; Tables [2 tables]; Whiteboards [4 boards]; Student workstations [30 desks]; Printers [1 printers] | 128h | 156,200 | 156,200 |
| 30 | 8.2 | **Marquez Library** |  | 13d | 2009-07-06 | 2009-07-22 |  | 2009-07-06 | 2009-07-22 | 13d | 8d |  |  |  |  | 208h | 271,400 | 271,400 |
| 31 | 8.2.1 | Build Lab L315 |  | 7d | 2009-07-14 | 2009-07-22 | 17, 18, 19, 20, 21, 22, 13 | 2009-07-14 | 2009-07-22 | 7d | 8d |  |  |  | Chairs [31 chairs]; Displays [31 monitors]; General Contractor [200%]; Instructor workstations [1 desks]; PC systems [31 PCs]; Projectors [2 units]; Scanners [1 scanners]; Screens [2 units]; Tables [2 tables]; Whiteboards [4 boards]; Student workstations [30 desks]; Printers [1 printers] | 112h | 156,200 | 156,200 |
| 32 | 8.2.2 | Build Lab L316 |  | 6d | 2009-07-06 | 2009-07-13 | 17, 18, 19, 20, 21, 22, 13 | 2009-07-06 | 2009-07-13 | 6d | 15d |  |  |  | Chairs [21 chairs]; General Contractor [200%]; Instructor workstations [1 desks]; Mac systems [21 Macs]; Projectors [2 units]; Scanners [1 scanners]; Screens [2 units]; Tables [2 tables]; Whiteboards [4 boards]; Student workstations [20 desks]; Printers [1 printers] | 96h | 115,200 | 115,200 |
| 33 | 8.3 | **Salam Center** |  | 21d | 2009-07-06 | 2009-08-04 |  | 2009-07-06 | 2009-08-04 | 21d | 0d |  |  |  |  | 320h | 407,100 | 407,100 |
| 34 | 8.3.1 | Build Lab S324 |  | 5d | 2009-07-28 | 2009-08-04 | 17, 18, 19, 20, 21, 22, 14 | 2009-07-28 | 2009-08-04 | 5d | 0d |  |  |  | Chairs [21 chairs]; Displays [21 monitors]; General Contractor [200%]; Instructor workstations [1 desks]; PC systems [21 PCs]; Projectors [2 units]; Scanners [1 scanners]; Screens [2 units]; Tables [2 tables]; Whiteboards [4 boards]; Student workstations [20 desks]; Printers [1 printers] | 80h | 115,200 | 115,200 |
| 35 | 8.3.2 | Build Lab S325 |  | 7d | 2009-07-16 | 2009-07-24 | 17, 18, 19, 20, 21, 22, 14 | 2009-07-16 | 2009-07-24 | 7d | 6d |  |  |  | Chairs [26 chairs]; Displays [26 monitors]; General Contractor [200%]; Instructor workstations [1 desks]; PC systems [26 PCs]; Projectors [2 units]; Scanners [1 scanners]; Screens [2 units]; Tables [2 tables]; Whiteboards [4 boards]; Student workstations [25 desks]; Printers [1 printers] | 112h | 135,700 | 135,700 |
| 36 | 8.3.3 | Build Lab S326 |  | 8d | 2009-07-06 | 2009-07-15 | 17, 18, 19, 20, 21, 22, 14 | 2009-07-06 | 2009-07-15 | 8d | 13d |  |  |  | Chairs [31 chairs]; Displays [31 monitors]; General Contractor [200%]; Instructor workstations [1 desks]; PC systems [31 PCs]; Projectors [2 units]; Scanners [1 scanners]; Screens [2 units]; Tables [2 tables]; Whiteboards [4 boards]; Student workstations [30 desks]; Printers [1 printers] | 128h | 156,200 | 156,200 |
| 37 | 8.4 | **Sen Building** |  | 20d | 2009-07-06 | 2009-07-31 |  | 2009-07-06 | 2009-07-31 | 20d | 1d |  |  |  |  | 304h | 407,100 | 407,100 |
| 38 | 8.4.1 | Build Lab E210 |  | 5d | 2009-07-27 | 2009-07-31 | 17, 18, 19, 20, 21, 22, 15 | 2009-07-27 | 2009-07-31 | 5d | 1d |  |  |  | Chairs [21 chairs]; Displays [21 monitors]; General Contractor [200%]; Instructor workstations [1 desks]; PC systems [21 PCs]; Projectors [2 units]; Scanners [1 scanners]; Screens [2 units]; Tables [2 tables]; Whiteboards [4 boards]; Student workstations [20 desks]; Printers [1 printers] | 80h | 115,200 | 115,200 |
| 39 | 8.4.2 | Build Lab E211 |  | 6d | 2009-07-16 | 2009-07-23 | 17, 18, 19, 20, 21, 22, 15 | 2009-07-16 | 2009-07-23 | 6d | 7d |  |  |  | Chairs [26 chairs]; Displays [26 monitors]; General Contractor [200%]; Instructor workstations [1 desks]; PC systems [26 PCs]; Projectors [2 units]; Scanners [1 scanners]; Screens [2 units]; Tables [2 tables]; Whiteboards [4 boards]; Student workstations [25 desks]; Printers [1 printers] | 96h | 135,700 | 135,700 |
| 40 | 8.4.3 | Build Lab E212 |  | 8d | 2009-07-06 | 2009-07-15 | 17, 18, 19, 20, 21, 22, 15 | 2009-07-06 | 2009-07-15 | 8d | 13d |  |  |  | Chairs [31 chairs]; Displays [31 monitors]; General Contractor [200%]; Instructor workstations [1 desks]; PC systems [31 PCs]; Projectors [2 units]; Scanners [1 scanners]; Screens [2 units]; Tables [2 tables]; Whiteboards [4 boards]; Student workstations [30 desks]; Printers [1 printers] | 128h | 156,200 | 156,200 |
| 41 | 8.5 | Lab construction started | milestone | 0d | 2009-07-06 | 2009-07-06 |  | 2009-07-06 | 2009-07-06 | 0d | 39d |  |  |  |  |  |  |  |
| 42 | 9 | **Commissioning** |  | 86d | 2009-04-21 | 2009-08-21 |  | 2009-04-21 | 2009-08-21 | 86d | 0d |  |  |  |  | 224h | 17,600 | 17,600 |
| 43 | 9.1 | Test all labs |  | 3d | 2009-08-05 | 2009-08-07 | 28, 29, 31, 32, 34, 35, 36, 38, 39, 40 | 2009-08-05 | 2009-08-07 | 3d | 10d | 0d |  |  | Project Manager [66.7%]; Information Systems Director [66.7%] | 32h | 1,200 | 1,200 |
| 44 | 9.2 | Produce as-built documents for all labs |  | 13d | 2009-08-05 | 2009-08-21 | 28, 29, 31, 32, 34, 35, 36, 38, 39, 40 | 2009-08-05 | 2009-08-21 | 13d | 0d |  |  |  | Interior Designer [15.4%]; Architect [15.4%]; Mechanical Consultant [15.4%]; Electrical Consultant [15.4%]; Security Consultant [15.4%]; Communications Consultant [15.4%]; General Contractor [15.4%] | 112h | 13,600 | 13,600 |
| 45 | 9.3 | Produce operations and maintenance manuals |  | 20d | 2009-04-21 | 2009-05-19 | 17, 18, 19, 20, 21, 22 | 2009-04-21 | 2009-05-19 | 20d | 66d | 0d |  |  | Information Systems Director [25%]; Facilities Manager [25%] | 80h | 2,800 | 2,800 |
| 46 | 10 | Operations manuals complete | milestone | 0d | 2009-05-19 | 2009-05-19 | 45 | 2009-05-19 | 2009-05-19 | 0d | 71d |  |  |  |  |  |  |  |
| 47 | 11 | Labs complete | milestone | 0d | 2009-08-07 | 2009-08-07 | 43 | 2009-08-07 | 2009-08-07 | 0d | 15d |  |  |  |  |  |  |  |
| 48 | 12 | Project complete | milestone | 0d | 2009-08-28 | 2009-08-28 | 5 | 2009-08-28 | 2009-08-28 | 0d | 0d |  |  | 2009-08-31 |  |  |  |  |

Notes:
- 26: A "Start no earlier than" constraint has been applied to Construction activities because rooms are being used until the end of June and will not be available for renovation until July 6.
- 29: Previously existing lab
- 32: Previously existing lab
- 35: Previously existing lab
- 36: Previously existing lab
- 40: Previously existing lab
